# cbio

Schedule from MS Project, 2006-01-09 to 2006-07-17, status date 2006-01-09, A marks actual dates.
Stanford University

## Calendars

- Standard: Mon-Fri 08:00-12:00, 13:00-17:00; Sat-Sun off. Exceptions (off unless hours are given): 2006-01-16, 2006-02-20, 2006-05-29, 2006-07-04.

## Resources

| Resource |
| --- |
| Lynn Murphy |
| Archana Vembakam |
| Daniel Rubin |

## Schedule

| ID | WBS | Task | Duration | Start | Finish | Predecessors | Total slack | Constraint | Resources | Work |
| --- | --- | --- | --- | --- | --- | --- | --- | --- | --- | --- |
| 1 | 1 | **Administrative** | 73.12d | 2006-01-09 | 2006-04-24 |  | 58.38d |  |  | 19h |
| 2 | 1.1 | **cBiO Stanford staff meeting** | 73.12d | 2006-01-09 | 2006-04-24 |  | 58.38d |  |  | 3h |
| 3 | 1.1.1 | cBiO Stanford staff meeting 1 | 1h | 2006-01-09 | 2006-01-09 |  | 77.88d | start no earlier than 2006-01-09 | Lynn Murphy; Archana Vembakam; Daniel Rubin | 3h |
| 4 | 1.1.2 | cBiO Stanford staff meeting 2 | 1h | 2006-01-23 | 2006-01-23 |  | 68.88d | start no earlier than 2006-01-23 |  |  |
| 5 | 1.1.3 | cBiO Stanford staff meeting 3 | 1h | 2006-01-30 | 2006-01-30 |  | 63.88d | start no earlier than 2006-01-30 |  |  |
| 6 | 1.1.4 | cBiO Stanford staff meeting 4 | 1h | 2006-02-06 | 2006-02-06 |  | 58.88d | start no earlier than 2006-02-06 |  |  |
| 7 | 1.1.5 | cBiO Stanford staff meeting 5 | 1h | 2006-02-13 | 2006-02-13 |  | 53.88d | start no earlier than 2006-02-13 |  |  |
| 8 | 1.1.6 | cBiO Stanford staff meeting 6 | 1h | 2006-02-27 | 2006-02-27 |  | 44.88d | start no earlier than 2006-02-27 |  |  |
| 9 | 1.1.7 | cBiO Stanford staff meeting 7 | 1h | 2006-03-06 | 2006-03-06 |  | 39.88d | start no earlier than 2006-03-06 |  |  |
| 10 | 1.1.8 | cBiO Stanford staff meeting 8 | 1h | 2006-03-13 | 2006-03-13 |  | 34.88d | start no earlier than 2006-03-13 |  |  |
| 11 | 1.1.9 | cBiO Stanford staff meeting 9 | 1h | 2006-03-20 | 2006-03-20 |  | 29.88d | start no earlier than 2006-03-20 |  |  |
| 12 | 1.1.10 | cBiO Stanford staff meeting 10 | 1h | 2006-03-27 | 2006-03-27 |  | 24.88d | start no earlier than 2006-03-27 |  |  |
| 13 | 1.1.11 | cBiO Stanford staff meeting 11 | 1h | 2006-04-03 | 2006-04-03 |  | 19.88d | start no earlier than 2006-04-03 |  |  |
| 14 | 1.1.12 | cBiO Stanford staff meeting 12 | 1h | 2006-04-10 | 2006-04-10 |  | 14.88d | start no earlier than 2006-04-10 |  |  |
| 15 | 1.1.13 | cBiO Stanford staff meeting 13 | 1h | 2006-04-17 | 2006-04-17 |  | 9.88d | start no earlier than 2006-04-17 |  |  |
| 16 | 1.1.14 | cBiO Stanford staff meeting 14 | 1h | 2006-04-24 | 2006-04-24 |  | 4.88d | start no earlier than 2006-04-24 |  |  |
| 17 | 1.2 | Protégé staff meeting | 1.5h | 2006-01-09 | 2006-01-09 |  | 77.81d | start no earlier than 2006-01-09 | Lynn Murphy; Archana Vembakam; Daniel Rubin | 4.5h |
| 18 | 1.3 | Site visit - Carol Bean | 4h | 2006-01-10 | 2006-01-10 |  | 76.5d | start no earlier than 2006-01-10 | Lynn Murphy; Archana Vembakam | 8h |
| 19 | 1.4 | IRT meeting | 1.5h | 2006-01-11 | 2006-01-11 |  | 75.81d | start no earlier than 2006-01-11 | Archana Vembakam | 1.5h |
| 20 | 1.5 | Protégé / NeOn | 1h | 2006-01-20 | 2006-01-20 |  | 77.88d | start no earlier than 2006-01-20 | Lynn Murphy; Archana Vembakam | 2h |
| 21 | 2 | **Website** | 13.5d | 2006-06-27 | 2006-07-17 |  | 0d |  |  | 104h |
| 22 | 2.1 | Logo design | 5d | 2006-06-27 | 2006-07-03 |  | 0d | as late as possible | Lynn Murphy | 40h |
| 23 | 2.2 | Design layout, color scheme, CSS | 2d | 2006-07-05 | 2006-07-06 | 22 | 0d |  | Lynn Murphy | 16h |
| 24 | 2.3 | MySQL integration | 2d | 2006-07-07 | 2006-07-10 | 23 | 0d |  | Lynn Murphy | 16h |
| 25 | 2.4 | Move content to new scheme | 1d | 2006-07-11 | 2006-07-11 | 24 | 0d |  | Lynn Murphy | 8h |
| 26 | 2.5 | Validity checks | 4h | 2006-07-12 | 2006-07-12 | 25 | 0d |  | Lynn Murphy | 4h |
| 27 | 2.6 | Statistics | 2d | 2006-07-12 | 2006-07-14 | 26, 39 | 0d |  | Lynn Murphy | 16h |
| 28 | 2.7 | Compose Terms of Use, Privacy Statement | 1d | 2006-07-14 | 2006-07-17 | 27 | 0d |  |  |  |
| 29 | 2.8 | Move to new production instance | 4h | 2006-07-17 | 2006-07-17 | 103 | 0d |  | Lynn Murphy | 4h |

| ID | WBS | Task | Type | Duration | Start | Finish | Predecessors | Complete | Remaining | Total slack | Free slack | Constraint | Resources | Work | Actual work |
| --- | --- | --- | --- | --- | --- | --- | --- | --- | --- | --- | --- | --- | --- | --- | --- |
| 30 | 3 | **Development Environment** |  | 6.5d | 2006-01-09 A | 2006-01-18 |  | 58% | 2.75d | 8.5d |  |  |  | 72h | 34h |
| 31 | 3.1 | Setup subversion project |  | 1d | 2006-01-09 A | 2006-01-09 A |  | 100% |  |  |  |  | Archana Vembakam | 8h | 8h |
| 32 | 3.2 | Determine directory structure |  | 0.5d | 2006-01-10 A | 2006-01-10 A | 31 | 100% |  |  |  |  | Archana Vembakam; Lynn Murphy | 8h | 8h |
| 33 | 3.3 | Build scripts |  | 3d | 2006-01-10 A | 2006-01-13 | 32 | 75% | 0.75d | 19.5d | 0d |  | Archana Vembakam | 24h | 18h |
| 34 | 3.4 | Setup internal bug tracking system |  | 2d | 2006-01-13 | 2006-01-18 | 33 |  |  | 16.5d | 0d |  | Lynn Murphy; Archana Vembakam | 32h |  |
| 35 | 3.5 | Development environment complete | milestone | 0d | 2006-01-18 | 2006-01-18 | 34 |  |  | 16.5d |  |  |  |  |  |
| 36 | 4 | **Analysis/Software Requirements** |  | 7d? | 2006-01-09 A | 2006-01-18 |  | 86% | 1d? | 5.43d | 0d |  |  | 80h | 72h |
| 37 | 4.1 | Research technology stack |  | 3d | 2006-01-09 A | 2006-01-11 A |  | 100% |  |  |  |  | Lynn Murphy; Archana Vembakam | 48h | 48h |
| 38 | 4.2 | Investigate LexGrid |  | 3d? | 2006-01-12 A | 2006-01-17 A | 37 | 100% |  |  |  | finish no earlier than 2006-01-13 | Archana Vembakam | 24h | 24h |
| 39 | 4.3 | Investigate statistics software |  | 1d? | 2006-01-18 | 2006-01-18 | 38 |  |  | 0d |  |  | Lynn Murphy | 8h |  |
| 40 | 4.4 | Analysis and software requirements complete | milestone | 0d | 2006-01-18 A | 2006-01-18 | 39 | 50% | 0d | 18.53d |  |  |  |  |  |
| 41 | 5 | **Design** |  | 7d? | 2006-01-19 A | 2006-01-27 | 36 | 63% | 2.57d? | 1d |  |  |  | 96h | 69.6h |
| 42 | 5.1 | Develop functional specifications |  | 2d | 2006-01-19 A | 2006-01-20 A |  | 100% |  |  |  |  | Lynn Murphy; Archana Vembakam | 32h | 32h |
| 43 | 5.2 | Prototype UI based on functional specifications |  | 1w | 2006-01-23 A | 2006-01-27 | 42 | 50% | 0.5w | 0d |  |  | Lynn Murphy | 40h | 20h |
| 44 | 5.3 | Prototype infrastructure functionality |  | 1d? | 2006-01-23 A | 2006-01-23 A | 42 | 100% |  |  |  |  | Archana Vembakam; Lynn Murphy | 16h | 16h |
| 45 | 5.4 | PROMPT prototype |  | 1d? | 2006-01-19 A | 2006-01-19 |  | 20% | 0.8d? | 6d |  |  | Archana Vembakam | 8h | 1.6h |
| 46 | 5.5 | Design complete | milestone | 0d | 2006-01-27 A | 2006-01-27 | 42, 43, 44, 45 | 40% | 0d | 14.1d | 0d |  |  |  |  |
| 47 | 6 | **Development** |  | 91d? | 2006-01-30 A | 2006-06-07 | 46, 35 | 32% | 62.02d? | -34d | 0d |  |  | 816h | 302.8h |
| 48 | 6.1 | **Phase 1** |  | 90d? | 2006-01-30 A | 2006-06-06 |  | 32% | 61.1d? | -33d | 0d |  |  | 816h | 302.8h |
| 49 | 6.1.1 | **Infrastructure** |  | 4d? | 2006-01-30 A | 2006-02-02 |  | 50% | 2d? | 0d |  |  |  | 32h | 16h |
| 50 | 6.1.1.1 | Exception Handling design |  | 2d? | 2006-02-01 A | 2006-02-02 |  | 50% | 1d? | -21d | 0d | start no earlier than 2006-02-01 | Archana Vembakam | 16h | 8h |
| 51 | 6.1.1.2 | Logging module |  | 2d | 2006-01-30 A | 2006-01-31 |  | 50% | 1d | -19d | 0d |  | Archana Vembakam | 16h | 8h |
| 52 | 6.1.2 | **Authorization and Authentication** |  | 30d? | 2006-02-03 A | 2006-03-17 | 49 | 64% | 10.76d? | -4d | 0d |  |  | 184h | 118h |
| 53 | 6.1.2.1 | Integration with JAAS |  | 1d? | 2006-02-03 A | 2006-02-03 A |  | 100% |  |  |  |  | Archana Vembakam | 8h | 8h |
| 54 | 6.1.2.2 | Integration with JavaMail |  | 1d? | 2006-02-06 A | 2006-02-06 | 53 | 75% | 0.25d? | -71d | 0d |  | Archana Vembakam | 8h | 6h |
| 55 | 6.1.2.3 | User EJB |  | 1d? | 2006-02-07 A | 2006-02-07 A | 54 | 100% |  |  |  |  | Archana Vembakam | 8h | 8h |

Notes:
- 39: Statistics software needs to work with both the cBiO website and the BioPortal. Integration issues possible as many open source packages are Apache based and not Tomcat based.

| ID | WBS | Task | Duration | Start | Finish | Predecessors | Complete | Remaining | Total slack | Free slack | Constraint | Resources | Work | Actual work |
| --- | --- | --- | --- | --- | --- | --- | --- | --- | --- | --- | --- | --- | --- | --- |
| 56 | 6.1.2.4 | **User Interface** | 20d | 2006-02-17 A | 2006-03-17 | 49 | 60% | 8d | -4d | 0d |  |  | 160h | 96h |
| 57 | 6.1.2.4.1 | Register | 2d | 2006-02-17 A | 2006-02-21 |  | 75% | 0.5d | -81d | 0d |  | Lynn Murphy | 16h | 12h |
| 58 | 6.1.2.4.2 | Sign In x2 | 3d | 2006-02-22 A | 2006-02-24 | 57 | 75% | 0.75d | -84d | 0d |  | Lynn Murphy | 24h | 18h |
| 59 | 6.1.2.4.3 | Sign Out | 1d | 2006-02-27 A | 2006-02-27 | 58 | 75% | 0.25d | -85d | 0d |  | Lynn Murphy | 8h | 6h |
| 60 | 6.1.2.4.4 | Account - details | 2d | 2006-02-28 A | 2006-03-01 | 59 | 75% | 0.5d | -87d | 0d |  | Lynn Murphy | 16h | 12h |
| 61 | 6.1.2.4.5 | Account - edit | 2d | 2006-03-02 A | 2006-03-03 | 60 | 75% | 0.5d | -89d | 0d |  | Lynn Murphy | 16h | 12h |
| 62 | 6.1.2.4.6 | Password - edit | 2d | 2006-03-06 A | 2006-03-07 | 61 | 75% | 0.5d | -91d | 0d |  | Lynn Murphy | 16h | 12h |
| 63 | 6.1.2.4.7 | Email - edit | 2d | 2006-03-08 A | 2006-03-09 | 62 | 75% | 0.5d | -93d | 0d |  | Lynn Murphy | 16h | 12h |
| 64 | 6.1.2.4.8 | Password assistance | 2d | 2006-03-10 A | 2006-03-13 | 63 | 75% | 0.5d | 0d |  |  | Lynn Murphy | 16h | 12h |
| 65 | 6.1.2.4.9 | Remember me - cookies | 4d | 2006-03-14 | 2006-03-17 | 64 |  |  | 0d |  |  | Lynn Murphy | 32h |  |
| 66 | 6.1.3 | **Ontology Metadata and Repository** | 38d? | 2006-03-20 A | 2006-05-10 | 52 | 29% | 26.95d? | -15d | 0d |  |  | 600h | 168.8h |
| 67 | 6.1.3.1 | Versioning | 2d? | 2006-03-20 A | 2006-03-21 |  | 75% | 0.5d? | -53d | 0d |  | Archana Vembakam | 16h | 12h |
| 68 | 6.1.3.2 | Text diff | 2d? | 2006-03-20 | 2006-03-21 |  |  |  | -55d | 0d |  | Archana Vembakam | 16h |  |
| 69 | 6.1.3.3 | PROMPT Diff | 2d? | 2006-03-22 | 2006-03-23 | 68 |  |  | -55d | 0d |  | Archana Vembakam | 16h |  |
| 70 | 6.1.3.4 | Understand metadata OWL parsing | 3d? | 2006-03-20 A | 2006-03-22 |  | 50% | 1.5d? | -6d | 0d | finish no earlier than 2006-03-14 | Archana Vembakam | 24h | 12h |
| 71 | 6.1.3.5 | Construct metadata instance file | 2d | 2006-03-23 A | 2006-03-24 | 70 | 50% | 1d | -56d | 0d |  | Archana Vembakam | 16h | 8h |
| 72 | 6.1.3.6 | Construct XML for metadata | 1d? | 2006-03-27 A | 2006-03-27 A | 71 | 100% |  |  |  |  |  |  |  |
| 73 | 6.1.3.7 | Metadata EJB | 2d? | 2006-03-27 A | 2006-03-28 | 72 | 75% | 0.5d? | -106d | 0d |  | Archana Vembakam | 16h | 12h |
| 74 | 6.1.3.8 | Ontology EJB | 3d? | 2006-03-20 A | 2006-03-22 |  | 75% | 0.75d? | -97d | 0d | start no earlier than 2006-03-16 | Archana Vembakam | 24h | 18h |
| 75 | 6.1.3.9 | Develop job framework | 7d? | 2006-03-21 A | 2006-03-29 |  | 25% | 5.25d? | -62d | 0d | start no earlier than 2006-03-21 | Archana Vembakam | 56h | 14h |
| 76 | 6.1.3.10 | Integrate Lexgrid | 3d? | 2006-03-30 | 2006-04-03 | 75 |  |  | -62d | 0d |  | Archana Vembakam | 24h |  |
| 77 | 6.1.3.11 | Testing | 5d | 2006-04-03 A | 2006-04-07 |  | 20% | 4d | -66d | 0d | start no earlier than 2006-04-03 | Archana Vembakam | 40h | 8h |
| 78 | 6.1.3.12 | Explore WebDAV | 5d | 2006-04-10 A | 2006-04-14 | 77 | 20% | 4d | -71d | 0d |  | Archana Vembakam | 40h | 8h |
| 79 | 6.1.3.13 | **User Interface** | 36d | 2006-03-22 A | 2006-05-10 |  | 25% | 27.14d | -15d | 0d |  |  | 312h | 76.8h |
| 80 | 6.1.3.13.1 | Ontology - list | 6d | 2006-03-22 A | 2006-03-29 | 74 | 50% | 3d | 0d |  |  | Lynn Murphy | 48h | 24h |
| 81 | 6.1.3.13.2 | Ontology - details | 3d | 2006-04-06 A | 2006-04-10 | 74, 82 | 60% | 1.2d | -85d | 0d |  | Lynn Murphy | 24h | 14.4h |
| 82 | 6.1.3.13.3 | Ontology - submit new | 5d | 2006-03-30 A | 2006-04-05 | 73, 80 | 40% | 3d | -85d | 0d |  | Lynn Murphy | 40h | 16h |
| 83 | 6.1.3.13.4 | Ontology - submit version | 3d | 2006-04-06 | 2006-04-10 | 82 |  |  | 0d |  |  | Lynn Murphy | 24h |  |
| 84 | 6.1.3.13.5 | Metadata - details | 7d | 2006-04-11 A | 2006-04-19 | 81, 83 | 40% | 4.2d | -107d | 0d |  | Lynn Murphy | 56h | 22.4h |
| 85 | 6.1.3.13.6 | Metadata - edit | 5d | 2006-04-20 | 2006-04-26 | 73, 84 |  |  | 0d |  |  | Lynn Murphy | 40h |  |
| 86 | 6.1.3.13.7 | Ontology versions - list | 3d | 2006-04-27 | 2006-05-01 | 74, 85 |  |  | -107d | 0d |  | Lynn Murphy | 24h |  |
| 87 | 6.1.3.13.8 | Ontology version - edit | 2d | 2006-05-02 | 2006-05-03 | 86 |  |  | 0d |  |  | Lynn Murphy | 16h |  |
| 88 | 6.1.3.13.9 | Ontology Management - list | 2d | 2006-05-04 | 2006-05-05 | 87 |  |  | 0d |  |  | Lynn Murphy | 16h |  |
| 89 | 6.1.3.13.10 | Ontology Librarian - categorize, review ontology | 3d | 2006-05-08 | 2006-05-10 | 88 |  |  | 0d |  |  | Lynn Murphy | 24h |  |

Notes:
- 56: All UI work consists of - / ·Visual and interaction design / ·JSP coding / ·Server side controller and model Java coding
- 58: 2 sign in pages are necessary. One for when user is not signed in and clicks on resource that is protected. The other is for when the user clicks on the sign in button (contains sign in information as well as registration pointers).
- 79: All UI work consists of - / ·Visual and interaction design / ·JSP coding / ·Server side controller and model Java coding
- 88: Librarian area which includes a list of ontologies awaiting categorization and review

| ID | WBS | Task | Type | Duration | Start | Finish | Predecessors | Complete | Remaining | Total slack | Free slack | Constraint | Resources |
| --- | --- | --- | --- | --- | --- | --- | --- | --- | --- | --- | --- | --- | --- |
| 90 | 6.1.4 | **User Interface - Miscellaneous** |  | 18d | 2006-05-11 | 2006-06-06 | 79 |  |  | -107d | 0d |  |  |
| 91 | 6.1.4.1 | Visual design - color scheme, tab design, etc. |  | 14d | 2006-05-11 | 2006-05-31 |  |  |  | 0d |  |  |  |
| 92 | 6.1.4.2 | Navigational design |  | 4d | 2006-06-01 | 2006-06-06 | 91 |  |  | 0d |  |  |  |
| 93 | 6.2 | Development complete |  | 1d? | 2006-06-07 | 2006-06-07 | 48 |  |  | 0d |  |  |  |
| 94 | 7 | **Testing** |  | 24d | 2006-06-07 | 2006-07-12 | 47 |  |  | -107d | 0d |  |  |
| 95 | 7.1 | Develop unit tests |  | 7d | 2006-06-08 | 2006-06-16 |  |  |  | 0d |  |  |  |
| 96 | 7.2 | Perform tests |  | 3d | 2006-06-19 | 2006-06-21 | 95 |  |  | 0d |  |  |  |
| 97 | 7.3 | Bug fixing |  | 14d | 2006-06-22 | 2006-07-12 | 96 |  |  | 0d |  |  |  |
| 98 | 7.4 | Testing complete | milestone | 0d | 2006-06-07 | 2006-06-07 |  |  |  | -83d | 0d |  |  |
| 99 | 8 | **Deployment** |  | 109d? | 2006-02-08 A | 2006-07-14 | 94 |  | 109d? | 0.5d |  |  |  |
| 100 | 8.1 | Define machine infrastructure requirements for IT | milestone | 0h | 2006-02-08 A | 2006-02-08 A |  | 100% |  |  |  |  | Lynn Murphy; Archana Vembakam |
| 101 | 8.2 | Define backup and recovery procedures for IT | milestone | 0h | 2006-02-27 A | 2006-02-27 A |  | 100% |  |  |  |  | Lynn Murphy; Archana Vembakam |
| 102 | 8.3 | Staging instance available |  | 1d? | 2006-07-13 | 2006-07-13 | 100, 101 |  |  | 1.5d |  | finish no earlier than 2006-04-14 |  |
| 103 | 8.4 | Production instance available |  | 1d? | 2006-07-14 | 2006-07-14 | 100, 101 |  |  | 0d |  | finish no earlier than 2006-07-14 |  |
| 104 | 8.5 | Deploy BioPortal Phase 1 |  | 1d | 2006-07-13 | 2006-07-13 | 35, 40, 46, 98 |  |  | 1.5d |  | finish no earlier than 2006-05-15 |  |
